# Datová migrace Hubtex

How a schedule from MS Project changed from version to version. A marks actual dates.

## Version 1 (data date 2007-01-26, saved 2008-02-02, file 22232_xpalm18.mpp)

| ID | WBS | Task | Duration | Start | Finish | Predecessors | Complete | Total float | Constraint |
| --- | --- | --- | --- | --- | --- | --- | --- | --- | --- |
| 1 |  | Zahájení projektu | 0d | 2007-01-15 09:00 A | 2007-01-15 09:00 A |  | 100% |  |  |
| 2 | 2 | **Přípravná fáze** | 42d | 2007-01-15 09:00 A | 2007-03-13 17:30 |  | 21% | 75d |  |
| 3 |  | Příprava a kopírování dat do databáze Access | 2d | 2007-01-15 09:00 A | 2007-01-17 09:00 A | 1 | 100% |  |  |
| 4 |  | Odeslání dat | 3d | 2007-01-17 09:00 A | 2007-01-19 17:30 A | 3 | 100% |  |  |
| 5 |  | Analýza struktury dat | 5d | 2007-01-22 09:00 A | 2007-01-26 17:30 A | 4 | 100% |  |  |
| 6 |  | Tvorba projektového plánu | 1d | 2007-01-29 09:00 | 2007-01-29 17:30 | 5 |  | 106d |  |
| 7 |  | Cesta Praha -> Fulda | 5eh | 2007-02-05 02:00 | 2007-02-05 07:00 | 8SF |  | 436.57d |  |
| 8 |  | Osobní schůzka v Hubtexu | 2d | 2007-02-05 07:00 | 2007-02-06 15:30 | 5 |  | 49d | start no earlier than 2007-02-05 07:00 |
| 9 |  | Cesta Fulda -> Praha | 5eh | 2007-02-06 15:30 | 2007-02-06 20:30 | 8 |  | 226.81d |  |
| 10 | 2.8 | **Příprava dat a tabulek** | 3.38d | 2007-02-07 09:00 | 2007-02-12 12:00 |  |  | 52.24d |  |
| 11 |  | Číselník dílů | 6h | 2007-02-07 09:00 | 2007-02-07 15:30 | 9 |  | 52.24d |  |
| 12 |  | Zákazníci | 4h | 2007-02-07 15:30 | 2007-02-08 11:00 | 11 |  | 52.24d |  |
| 13 |  | Dodavatelé | 4h | 2007-02-08 11:00 | 2007-02-08 15:30 | 12 |  | 52.24d |  |
| 14 |  | Nákupní ceny | 2h | 2007-02-08 15:30 | 2007-02-08 17:30 | 13 |  | 52.24d |  |
| 15 |  | Prodejní ceny | 4h | 2007-02-09 09:00 | 2007-02-09 13:30 | 14 |  | 52.24d |  |
| 16 |  | Zakázky | 7h | 2007-02-09 13:30 | 2007-02-12 12:00 | 15 |  | 52.24d |  |
| 17 |  | Kusovníky | 3h | 2007-02-07 09:00 | 2007-02-07 12:00 | 11SS |  | 98.5d |  |
| 18 |  | Pracovní postupy | 5h | 2007-02-07 12:00 | 2007-02-07 17:30 | 17 |  | 98.5d |  |
| 19 |  | Objednávky | 4h | 2007-02-08 09:00 | 2007-02-08 13:30 | 18 |  | 98.5d |  |
| 20 | 2.9 | **Nastavení migračního programu** | 21.62d | 2007-02-12 12:00 | 2007-03-13 17:30 |  |  | 52.24d |  |
| 21 |  | Číselník dílů | 39h | 2007-02-12 12:00 | 2007-02-19 11:00 | 16 |  | 52.24d |  |
| 22 |  | Zákazníci | 28.5h | 2007-02-19 11:00 | 2007-02-22 16:00 | 21 |  | 52.24d |  |
| 23 |  | Dodavatelé | 28.5h | 2007-02-22 16:00 | 2007-02-28 12:00 | 22 |  | 52.24d |  |
| 24 |  | Nákupní ceny | 10h | 2007-02-28 12:00 | 2007-03-01 14:30 | 23 |  | 52.24d |  |
| 25 |  | Prodejní ceny | 23h | 2007-03-01 14:30 | 2007-03-06 13:30 | 24 |  | 52.24d |  |
| 26 |  | Zakázky | 44h | 2007-03-06 13:30 | 2007-03-13 17:30 | 25 |  | 52.24d |  |
| 27 |  | Kusovníky | 10h | 2007-02-12 12:00 | 2007-02-13 14:30 | 21SS |  | 88.62d |  |
| 28 |  | Pracovní postupy | 32h | 2007-02-13 14:30 | 2007-02-19 14:30 | 27 |  | 88.62d |  |
| 29 |  | Objednávky | 22h | 2007-02-19 14:30 | 2007-02-22 12:00 | 28 |  | 88.62d |  |
| 30 |  | Ukončení přípravné fáze | 0d | 2007-03-13 17:30 | 2007-03-13 17:30 | 26 |  | 52.24d |  |
| 31 | 4 | **Testovací fáze** | 19.63d | 2007-03-14 09:00 | 2007-04-11 14:32 |  |  | 52.24d |  |
| 32 | 4.1 | **První testování** | 8.75d | 2007-03-14 09:00 | 2007-03-26 15:30 |  |  | 52.24d |  |
| 33 | 4.1.1 | **Načtení dat pro první testování** | 1.88d | 2007-03-14 09:00 | 2007-03-15 16:30 |  |  | 52.24d |  |
| 34 |  | Číselník dílů | 3h | 2007-03-14 09:00 | 2007-03-14 12:00 | 30 |  | 52.24d |  |
| 35 |  | Zákazníci | 1h | 2007-03-14 12:00 | 2007-03-14 13:30 | 34 |  | 73.62d |  |
| 36 |  | Dodavatelé | 1h | 2007-03-14 13:30 | 2007-03-14 14:30 | 35 |  | 73.62d |  |
| 37 |  | Nákupní ceny | 2h | 2007-03-14 14:30 | 2007-03-14 16:30 | 36 |  | 73.62d |  |
| 38 |  | Prodejní ceny | 1h | 2007-03-14 16:30 | 2007-03-14 17:30 | 37 |  | 73.62d |  |
| 39 |  | Zakázky | 3h | 2007-03-15 09:00 | 2007-03-15 12:00 | 38 |  | 73.62d |  |
| 40 |  | Kusovníky | 2h | 2007-03-14 12:00 | 2007-03-14 14:30 | 34 |  | 52.24d |  |
| 41 |  | Pracovní postupy | 8h | 2007-03-14 14:30 | 2007-03-15 14:30 | 40 |  | 52.24d |  |
| 42 |  | Objednávky | 2h | 2007-03-15 14:30 | 2007-03-15 16:30 | 41 |  | 52.24d |  |
| 43 |  | Testování načtených dat | 1w | 2007-03-16 07:00 | 2007-03-22 15:30 | 42 |  | 51.37d |  |
| 44 |  | Úpravy a opravy po prvním testování | 2d | 2007-03-22 15:30 | 2007-03-26 15:30 | 43 |  | 54.37d |  |
| 45 | 4.2 | **Druhé testování** | 7.88d | 2007-03-26 15:30 | 2007-04-05 14:32 |  |  | 54.37d |  |
| 46 |  | Načtení dat pro druhé testování | 1.88d | 2007-03-26 15:30 | 2007-03-28 14:32 | 44 |  | 54.37d |  |
| 47 |  | Testování načtených dat | 1w | 2007-03-28 14:32 | 2007-04-04 14:32 | 46 |  | 50.37d |  |
| 48 |  | Úpravy a opravy po druhém testování | 1d | 2007-04-04 14:32 | 2007-04-05 14:32 | 47 |  | 54.37d |  |
| 49 |  | Tvorba a kompletace dokumentace | 3d | 2007-04-05 14:32 | 2007-04-11 14:32 | 48 |  | 54.37d |  |
| 50 |  | Fakturace testovací fáze | 1h | 2007-04-05 14:32 | 2007-04-05 15:32 | 48 |  | 58.24d |  |
| 51 |  | Ukončení testovací fáze | 0d | 2007-04-11 14:32 | 2007-04-11 14:32 | 49 |  | 54.37d |  |
| 52 | 6 | **Ostrý provoz** | 2.32d | 2007-06-29 03:00 | 2007-06-30 14:32 |  |  | 0d |  |
| 53 |  | Cesta Praha -> Fulda | 5eh | 2007-06-29 03:00 | 2007-06-29 08:00 | 54SF |  | 4.44d |  |
| 54 |  | Obdržení aktuálních dat | 0.5h | 2007-06-29 08:00 | 2007-06-29 08:30 | 51 |  | 0d | start no earlier than 2007-06-29 07:00 |
| 55 |  | Úprava nových dat | 3h | 2007-06-29 08:30 | 2007-06-29 11:30 | 54 |  | 0d |  |
| 56 |  | Načtení dat do "živého" systému | 1.88d | 2007-06-29 11:30 | 2007-06-30 14:32 | 55 |  | 0d |  |
| 57 |  | Uvedení do ostrého provozu | 0d | 2007-06-30 14:32 | 2007-06-30 14:32 | 56 |  | 0d |  |
| 58 |  | Cesta Fulda -> Praha | 5eh | 2007-06-30 14:32 | 2007-06-30 19:32 | 57 |  | 0d |  |
| 59 |  | Fakturace uvedení dat do ostrého provozu | 1eh | 2007-06-30 14:32 | 2007-06-30 15:32 | 57 |  | 0.5d |  |
| 60 |  | Ukončení projektu | 0d | 2007-06-30 19:32 | 2007-06-30 19:32 | 58 |  | 0d |  |

## Version 2 (data date 2007-01-30, saved 2008-02-03, file 22233_xpalm18.mpp)

Last finish stays 2007-06-30.

Added:

| ID | Task | Duration | Start | Finish | Constraint | Resources |
| --- | --- | --- | --- | --- | --- | --- |
| 62 | **Zúčtování fixních nákladů** | 62d | 2007-01-31 09:00 | 2007-04-30 09:00 |  |  |
| 63 | Zúčtování fixních nákladů 1/2007 | 0d | 2007-01-31 09:00 | 2007-01-31 09:00 | start no earlier than 2007-01-31 09:00 | kanceláře Praha [50%]; ADSL připojení k internetu [50%]; CDMA připojení k internetu [50%]; hovorné [50%]; notebooky [50%]; mobilní telefony [50%] |
| 64 | Zúčtování fixních nákladů 2/2007 | 0d | 2007-02-28 09:00 | 2007-02-28 09:00 | start no earlier than 2007-02-28 09:00 | kanceláře Praha; ADSL připojení k internetu; CDMA připojení k internetu; hovorné; notebooky; mobilní telefony |
| 65 | Zúčtování fixních nákladů 3/2007 | 0d | 2007-03-31 09:00 | 2007-03-31 09:00 | start no earlier than 2007-03-31 09:00 | kanceláře Praha; ADSL připojení k internetu; CDMA připojení k internetu; hovorné; notebooky; mobilní telefony |
| 66 | Zúčtování fixních nákladů 4/2007 | 0d | 2007-04-30 09:00 | 2007-04-30 09:00 | start no earlier than 2007-04-30 09:00 | kanceláře Praha [50%]; ADSL připojení k internetu [50%]; CDMA připojení k internetu [50%]; hovorné [50%]; notebooky [50%]; mobilní telefony [50%] |

Changed:

| ID | Task | Start | Finish | Duration | Complete | Total float | Other |
| --- | --- | --- | --- | --- | --- | --- | --- |
| 1 | Zahájení projektu |  |  |  |  |  | baseline start 2007-01-15 09:00 → none; baseline finish 2007-01-15 09:00 → none |
| 2 | **Přípravná fáze** |  | 2007-03-13 17:30 → 2007-03-15 15:30 (+2d) | 42d → 43.75d | 21% → 22% | 75d → 73.25d | baseline start 2007-01-15 09:00 → none; baseline finish 2007-03-14 14:00 → none |
| 3 | Příprava a kopírování dat do databáze Access |  |  |  |  |  | resources none → zaměstnanec Schulte-Henke; baseline start 2007-01-15 09:00 → none; baseline finish 2007-01-17 09:00 → none |
| 4 | Odeslání dat |  |  | 3d → 2.75d |  |  | resources none → zaměstnanec Schulte-Henke [5.5%]; baseline start 2007-01-17 09:00 → none; baseline finish 2007-01-19 17:30 → none |
| 5 | Analýza struktury dat |  | 2007-01-26 17:30 A → 2007-01-30 13:30 A (+4d) | 5d → 6.12d |  |  | resources none → Mirek Pala [25%]; Albert Höfer [75%]; baseline start 2007-01-22 09:00 → none; baseline finish 2007-01-26 17:30 → none |
| 6 | Tvorba projektového plánu | 2007-01-29 09:00 → 2007-01-30 13:30 (+1d) | 2007-01-29 17:30 → 2007-01-31 13:30 (+2d) |  |  | 106d → 104.5d | resources none → Mirek Pala; baseline start 2007-01-29 09:00 → none; baseline finish 2007-01-29 17:30 → none |
| 7 | Cesta Praha -> Fulda |  |  |  |  |  | resources none → Thomas König; Mirek Pala; osobní automobil Škoda Octavia RS [500 km]; baseline start 2007-02-05 04:00 → none; baseline finish 2007-02-05 09:00 → none |
| 8 | Osobní schůzka v Hubtexu |  |  |  |  | 49d → 45d | resources none → Thomas König; Mirek Pala; zaměstnanec Hubtex [200%]; zaměstnanec Schulte-Henke [200%]; diety [2 ks]; baseline start 2007-02-05 09:00 → none; baseline finish 2007-02-07 09:00 → none |
| 9 | Cesta Fulda -> Praha |  |  |  |  | 226.81d → 206.37d | resources none → Thomas König; osobní automobil Škoda Octavia RS [500 km]; Mirek Pala; baseline start 2007-02-07 09:00 → none; baseline finish 2007-02-07 14:00 → none |
| 10 | **Příprava dat a tabulek** |  | 2007-02-12 12:00 → 2007-02-12 14:30 | 3.38d → 3.62d |  | 52.24d → 47.74d | baseline start 2007-02-07 14:00 → none; baseline finish 2007-02-12 17:00 → none |
| 11 | Číselník dílů |  |  |  |  | 52.24d → 47.74d | resources none → Mirek Pala; baseline start 2007-02-07 14:00 → none; baseline finish 2007-02-08 11:30 → none |
| 12 | Zákazníci |  | 2007-02-08 11:00 → 2007-02-08 15:30 |  |  | 52.24d → 47.24d | resources none → Mirek Pala; baseline start 2007-02-08 11:30 → none; baseline finish 2007-02-08 16:00 → none |
| 13 | Dodavatelé | 2007-02-08 11:00 → 2007-02-08 15:30 | 2007-02-08 15:30 → 2007-02-08 23:00 |  |  | 52.24d → 47.24d | resources none → Mirek Pala; baseline start 2007-02-08 16:00 → none; baseline finish 2007-02-09 11:30 → none |
| 14 | Nákupní ceny | 2007-02-08 15:30 → 2007-02-09 09:00 (+1d) | 2007-02-08 17:30 → 2007-02-09 11:00 (+1d) |  |  | 52.24d → 47.49d | resources none → Mirek Pala; baseline start 2007-02-09 11:30 → none; baseline finish 2007-02-09 14:00 → none |
| 15 | Prodejní ceny | 2007-02-09 09:00 → 2007-02-09 11:00 | 2007-02-09 13:30 → 2007-02-09 15:30 |  |  | 52.24d → 47.49d | resources none → Mirek Pala; baseline start 2007-02-09 14:00 → none; baseline finish 2007-02-12 09:30 → none |
| 16 | Zakázky | 2007-02-09 13:30 → 2007-02-09 15:30 | 2007-02-12 12:00 → 2007-02-12 14:30 |  |  | 52.24d → 47.74d | resources none → Mirek Pala; baseline start 2007-02-12 09:30 → none; baseline finish 2007-02-12 17:00 → none |
| 17 | Kusovníky |  |  |  |  | 98.5d → 98.56d | resources none → Albert Höfer; baseline start 2007-02-07 14:00 → none; baseline finish 2007-02-07 17:00 → none |
| 18 | Pracovní postupy |  |  |  |  |  | resources none → Albert Höfer; baseline start 2007-02-07 17:00 → none; baseline finish 2007-02-08 14:00 → none |
| 19 | Objednávky | 2007-02-08 09:00 → 2007-02-08 14:00 | 2007-02-08 13:30 → 2007-02-08 18:00 |  |  | 98.5d → 97.94d | resources none → Albert Höfer; baseline start 2007-02-08 14:00 → none; baseline finish 2007-02-09 09:30 → none |
| 20 | **Nastavení migračního programu** | 2007-02-12 12:00 → 2007-02-12 14:30 | 2007-03-13 17:30 → 2007-03-15 15:30 (+2d) | 21.62d → 23.12d |  | 52.24d → 47.74d | baseline start 2007-02-12 17:00 → none; baseline finish 2007-03-14 14:00 → none |
| 21 | Číselník dílů | 2007-02-12 12:00 → 2007-02-12 14:30 | 2007-02-19 11:00 → 2007-02-19 15:30 |  |  | 52.24d → 47.74d | resources none → Mirek Pala; baseline start 2007-02-12 17:00 → none; baseline finish 2007-02-19 16:00 → none |
| 22 | Zákazníci | 2007-02-19 11:00 → 2007-02-19 15:30 | 2007-02-22 16:00 → 2007-02-23 14:00 (+1d) |  |  | 52.24d → 47.74d | resources none → Mirek Pala; baseline start 2007-02-19 16:00 → none; baseline finish 2007-02-23 12:00 → none |
| 23 | Dodavatelé | 2007-02-22 16:00 → 2007-02-23 14:00 (+1d) | 2007-02-28 12:00 → 2007-03-01 14:30 (+1d) |  |  | 52.24d → 47.49d | resources none → Mirek Pala; baseline start 2007-02-23 12:00 → none; baseline finish 2007-02-28 17:00 → none |
| 24 | Nákupní ceny | 2007-02-28 12:00 → 2007-03-01 14:30 (+1d) | 2007-03-01 14:30 → 2007-03-02 14:30 (+1d) |  |  | 52.24d → 47.49d | resources none → Mirek Pala; baseline start 2007-02-28 17:00 → none; baseline finish 2007-03-02 10:30 → none |
| 25 | Prodejní ceny | 2007-03-01 14:30 → 2007-03-02 14:30 (+1d) | 2007-03-06 13:30 → 2007-03-07 13:30 (+1d) |  |  | 52.24d → 47.74d | resources none → Mirek Pala; baseline start 2007-03-02 10:30 → none; baseline finish 2007-03-07 09:30 → none |
| 26 | Zakázky | 2007-03-06 13:30 → 2007-03-07 13:30 (+1d) | 2007-03-13 17:30 → 2007-03-15 15:30 (+2d) |  |  | 52.24d → 47.49d | resources none → Mirek Pala; baseline start 2007-03-07 09:30 → none; baseline finish 2007-03-14 14:00 → none |
| 27 | Kusovníky | 2007-02-12 12:00 → 2007-02-12 14:30 | 2007-02-13 14:30 → 2007-02-13 16:00 |  |  | 88.62d → 86.94d | resources none → Albert Höfer; baseline start 2007-02-12 17:00 → none; baseline finish 2007-02-14 10:30 → none |
| 28 | Pracovní postupy | 2007-02-13 14:30 → 2007-02-13 16:00 | 2007-02-19 14:30 → 2007-02-20 16:00 (+1d) |  |  | 88.62d → 86.94d | resources none → Albert Höfer; baseline start 2007-02-14 10:30 → none; baseline finish 2007-02-20 10:30 → none |
| 29 | Objednávky | 2007-02-19 14:30 → 2007-02-20 16:00 (+1d) | 2007-02-22 12:00 → 2007-02-26 14:30 (+4d) |  |  | 88.62d → 86.38d | resources none → Albert Höfer; baseline start 2007-02-20 10:30 → none; baseline finish 2007-02-22 17:00 → none |
| 30 | Ukončení přípravné fáze | 2007-03-13 17:30 → 2007-03-15 15:30 (+2d) | 2007-03-13 17:30 → 2007-03-15 15:30 (+2d) |  |  | 52.24d → 47.49d | baseline start 2007-03-14 14:00 → none; baseline finish 2007-03-14 14:00 → none |
| 31 | **Testovací fáze** | 2007-03-14 09:00 → 2007-03-15 15:30 (+1d) | 2007-04-11 14:32 → 2007-04-16 16:00 (+5d) | 19.63d → 21.06d |  | 52.24d → 47.49d | baseline start 2007-03-14 14:00 → none; baseline finish 2007-04-06 11:32 → none |
| 32 | **První testování** | 2007-03-14 09:00 → 2007-03-15 15:30 (+1d) | 2007-03-26 15:30 → 2007-03-28 15:30 (+2d) | 8.75d → 9d |  | 52.24d → 47.49d | baseline start 2007-03-14 14:00 → none; baseline finish 2007-03-27 13:00 → none |
| 33 | **Načtení dat pro první testování** | 2007-03-14 09:00 → 2007-03-15 15:30 (+1d) | 2007-03-15 16:30 → 2007-03-19 18:00 (+4d) | 1.88d → 2.25d |  | 52.24d → 47.49d | baseline start 2007-03-14 14:00 → none; baseline finish 2007-03-16 13:00 → none |
| 34 | Číselník dílů | 2007-03-14 09:00 → 2007-03-15 15:30 (+1d) | 2007-03-14 12:00 → 2007-03-15 22:00 (+1d) |  |  | 52.24d → 47.49d | resources none → Mirek Pala; baseline start 2007-03-14 14:00 → none; baseline finish 2007-03-14 17:00 → none |
| 35 | Zákazníci | 2007-03-14 12:00 → 2007-03-15 22:00 (+1d) | 2007-03-14 13:30 → 2007-03-15 23:00 (+1d) |  |  | 73.62d → 72d | resources none → Mirek Pala; baseline start 2007-03-14 17:00 → none; baseline finish 2007-03-15 09:30 → none |
| 36 | Dodavatelé | 2007-03-14 13:30 → 2007-03-16 09:00 (+2d) | 2007-03-14 14:30 → 2007-03-16 10:00 (+2d) |  |  | 73.62d → 72.12d | resources none → Mirek Pala; baseline start 2007-03-15 09:30 → none; baseline finish 2007-03-15 10:30 → none |
| 37 | Nákupní ceny | 2007-03-14 14:30 → 2007-03-16 10:00 (+2d) | 2007-03-14 16:30 → 2007-03-16 12:00 (+2d) |  |  | 73.62d → 72.12d | resources none → Mirek Pala; baseline start 2007-03-15 10:30 → none; baseline finish 2007-03-15 13:00 → none |
| 38 | Prodejní ceny | 2007-03-14 16:30 → 2007-03-16 12:00 (+2d) | 2007-03-14 17:30 → 2007-03-16 13:30 (+2d) |  |  | 73.62d → 72.12d | resources none → Mirek Pala; baseline start 2007-03-15 13:00 → none; baseline finish 2007-03-15 14:00 → none |
| 39 | Zakázky | 2007-03-15 09:00 → 2007-03-16 13:30 (+1d) | 2007-03-15 12:00 → 2007-03-16 16:30 (+1d) |  |  | 73.62d → 72.12d | resources none → Mirek Pala; baseline start 2007-03-15 14:00 → none; baseline finish 2007-03-15 17:00 → none |
| 40 | Kusovníky | 2007-03-14 12:00 → 2007-03-16 09:00 (+2d) | 2007-03-14 14:30 → 2007-03-16 11:00 (+2d) |  |  | 52.24d → 47.62d | resources none → Albert Höfer; baseline start 2007-03-14 17:00 → none; baseline finish 2007-03-15 10:30 → none |
| 41 | Pracovní postupy | 2007-03-14 14:30 → 2007-03-16 11:00 (+2d) | 2007-03-15 14:30 → 2007-03-19 16:00 (+4d) |  |  | 52.24d → 47.56d | resources none → Albert Höfer; baseline start 2007-03-15 10:30 → none; baseline finish 2007-03-16 10:30 → none |
| 42 | Objednávky | 2007-03-15 14:30 → 2007-03-19 16:00 (+4d) | 2007-03-15 16:30 → 2007-03-19 18:00 (+4d) |  |  | 52.24d → 47.56d | resources none → Albert Höfer; baseline start 2007-03-16 10:30 → none; baseline finish 2007-03-16 13:00 → none |
| 43 | Testování načtených dat | 2007-03-16 07:00 → 2007-03-20 07:00 (+4d) | 2007-03-22 15:30 → 2007-03-26 15:30 (+4d) |  |  | 51.37d → 46.87d | resources none → zaměstnanec Schulte-Henke [200%]; zaměstnanec Hubtex; baseline start 2007-03-16 13:00 → none; baseline finish 2007-03-23 13:00 → none |
| 44 | Úpravy a opravy po prvním testování | 2007-03-22 15:30 → 2007-03-26 15:30 (+4d) | 2007-03-26 15:30 → 2007-03-28 15:30 (+2d) | 2d → 2.06d |  | 54.37d → 49.87d | resources none → Mirek Pala; Albert Höfer; baseline start 2007-03-23 13:00 → none; baseline finish 2007-03-27 13:00 → none |
| 45 | **Druhé testování** | 2007-03-26 15:30 → 2007-03-28 15:30 (+2d) | 2007-04-05 14:32 → 2007-04-10 15:30 (+5d) | 7.88d → 8d |  | 54.37d → 50.31d | baseline start 2007-03-27 13:00 → none; baseline finish 2007-04-06 11:32 → none |
| 46 | Načtení dat pro druhé testování | 2007-03-26 15:30 → 2007-03-28 15:30 (+2d) | 2007-03-28 14:32 → 2007-03-30 16:32 (+2d) | 1.88d → 1.94d |  | 54.37d → 50.12d | resources none → Mirek Pala; Albert Höfer; baseline start 2007-03-27 13:00 → none; baseline finish 2007-03-29 11:32 → none |
| 47 | Testování načtených dat | 2007-03-28 14:32 → 2007-04-02 07:00 (+5d) | 2007-04-04 14:32 → 2007-04-06 15:30 (+2d) |  |  | 50.37d → 47.25d | resources none → zaměstnanec Schulte-Henke [200%]; zaměstnanec Hubtex; baseline start 2007-03-29 11:32 → none; baseline finish 2007-04-05 11:32 → none |
| 48 | Úpravy a opravy po druhém testování | 2007-04-04 14:32 → 2007-04-06 15:30 (+2d) | 2007-04-05 14:32 → 2007-04-10 15:30 (+5d) |  |  | 54.37d → 51.25d | resources none → Mirek Pala; Albert Höfer; baseline start 2007-04-05 11:32 → none; baseline finish 2007-04-06 11:32 → none |
| 49 | Tvorba a kompletace dokumentace | 2007-04-05 14:32 → 2007-04-10 15:30 (+5d) | 2007-04-11 14:32 → 2007-04-16 16:00 (+5d) | 3d → 3.31d |  | 54.37d → 51.19d | resources none → Mirek Pala; Albert Höfer [50%]; baseline start 2007-04-06 11:32 → none; baseline finish 2007-04-12 11:32 → none |
| 50 | Fakturace testovací fáze | 2007-04-05 14:32 → 2007-04-10 15:30 (+5d) | 2007-04-05 15:32 → 2007-04-10 16:30 (+5d) |  |  | 58.24d → 56.12d | resources none → Thomas König; baseline start 2007-04-06 11:32 → none; baseline finish 2007-04-06 13:02 → none |
| 51 | Ukončení testovací fáze | 2007-04-11 14:32 → 2007-04-16 16:00 (+5d) | 2007-04-11 14:32 → 2007-04-16 16:00 (+5d) |  |  | 54.37d → 51.19d | baseline start 2007-04-06 11:32 → none; baseline finish 2007-04-06 11:32 → none |
| 52 | **Ostrý provoz** |  |  |  |  |  | baseline start 2007-06-29 03:00 → none; baseline finish 2007-06-30 14:32 → none |
| 53 | Cesta Praha -> Fulda |  |  |  |  |  | resources none → Mirek Pala; Albert Höfer; osobní automobil BMW 523i [500 km]; baseline start 2007-06-29 03:00 → none; baseline finish 2007-06-29 08:00 → none |
| 54 | Obdržení aktuálních dat |  |  |  |  |  | resources none → Mirek Pala; Albert Höfer; zaměstnanec Hubtex; baseline start 2007-06-29 08:00 → none; baseline finish 2007-06-29 08:30 → none |
| 55 | Úprava nových dat |  |  |  |  |  | resources none → Mirek Pala; Albert Höfer; baseline start 2007-06-29 08:30 → none; baseline finish 2007-06-29 11:30 → none |
| 56 | Načtení dat do "živého" systému |  |  |  |  |  | resources none → Mirek Pala; Albert Höfer; zaměstnanec Hubtex [10%]; diety [4 ks]; baseline start 2007-06-29 11:30 → none; baseline finish 2007-06-30 14:32 → none |
| 57 | Uvedení do ostrého provozu |  |  |  |  |  | resources none → provize konzultantů; baseline start 2007-06-30 14:32 → none; baseline finish 2007-06-30 14:32 → none |
| 58 | Cesta Fulda -> Praha |  |  |  |  |  | resources none → Mirek Pala; Albert Höfer; osobní automobil BMW 523i [500 km]; baseline start 2007-06-30 14:32 → none; baseline finish 2007-06-30 19:32 → none |
| 59 | Fakturace uvedení dat do ostrého provozu |  |  |  |  |  | resources none → Thomas König; baseline start 2007-06-30 14:32 → none; baseline finish 2007-06-30 15:32 → none |
| 60 | Ukončení projektu |  |  |  |  |  | baseline start 2007-06-30 19:32 → none; baseline finish 2007-06-30 19:32 → none |
